# created_wbs

Schedule from MS Project, 2016-01-01 to 2016-10-06, status date 2016-03-01, costs in $, A marks actual dates.

## Calendars

- Standard: Mon-Fri 08:00-12:00, 13:00-17:00; Sat-Sun off.

## Resources

| Resource | Unit | Rate |
| --- | --- | --- |
| Project Manager |  | 35 |
| Associate Project Manager |  | 28 |
| Purchase Controller |  | 22 |
| Cybersecurity Analyst |  | 40 |
| Network Consultant |  | 30 |
| Infrastructure Engineer |  | 70 |
| Business Administrator |  | 23 |
| Software Development Manager |  | 28 |
| QA Engineer |  | 25 |
| Database Manager |  | 32 |
| Trainer |  | 15 |
| Intuit QuickBooks 2016 | License | 3200 |
| Symantec Antivirus | License | 72.64 |
| Claims Software | License | 85.26 |
| Google Apps | License | 20 |
| Broadband Service | License | 450 |
| Oracle Database Software | License | 7700 |
| Laptop | Unit | 899.99 |
| Printer | Unit | 432.55 |
| Router | Unit | 119.99 |
| Switch | Unit | 127.99 |
| WiFi Router | Unit | 51.99 |
| WiFi Range Extender | Unit | 148.12 |
| Firewall | Unit | 184.99 |
| Junction Box | Unit | 151.6 |
| RJ-45 Outlet | Unit | 4.62 |
| RJ-45 Connector Tips | Pack | 9.49 |
| Cat 6e Cable | Unit | 169.99 |
| Docking Station | Unit | 219.99 |
| Keyboard/Mouse | Unit | 79.99 |
| Monitor | Unit | 99.99 |
| Surge Protector | Unit | 20.99 |
| HIPAA Auditor |  | 20000 |
| Finance Manager |  | 40 |

## Schedule

| ID | WBS | Task | Duration | Start | Finish | Predecessors | Complete | Remaining | Actual start | Baseline start | Baseline finish | Baseline duration | Total slack | Constraint | Resources | Work | Actual work | Cost | Baseline cost | Actual cost |
| --- | --- | --- | --- | --- | --- | --- | --- | --- | --- | --- | --- | --- | --- | --- | --- | --- | --- | --- | --- | --- |
| 1 | 1 | **1 IT SYSTEM FOR MARLEY'S DENTAL CLINIC** | 109d | 2016-01-01 A | 2016-06-01 |  | 25% | 81.44d |  | 2016-01-01 | 2016-06-01 | 109d |  |  |  | 2080h | 456h | 128,370.03 | 94,831.08 | 19,672 |
| 2 | 1.1 | **1.1 Develop Budget** | 21d | 2016-01-01 A | 2016-01-29 |  | 99% | 0d |  | 2016-01-01 | 2016-01-29 | 21d | 0d |  |  | 312h | 264h | 10,304 | 10,304 | 8,384 |
| 3 | 1.1.1 | 1.1.1 Determine Support Cost | 2d | 2016-01-01 A | 2016-01-04 A |  | 100% |  |  | 2016-01-01 | 2016-01-04 | 2d |  |  | Purchase Controller | 16h | 16h | 352 | 352 | 352 |
| 4 | 1.1.2 | 1.1.2 Determine Software Cost | 3d | 2016-01-05 A | 2016-01-20 A |  | 100% |  |  | 2016-01-05 | 2016-01-20 | 3d |  | start no earlier than 2016-01-04 | Purchase Controller | 24h | 24h | 528 | 528 | 528 |
| 5 | 1.1.3 | 1.1.3 Determine Hardware Costs | 3d | 2016-01-06 A | 2016-01-08 A |  | 100% |  |  | 2016-01-06 | 2016-01-08 | 3d |  | start no earlier than 2016-01-06 | Purchase Controller | 24h | 24h | 528 | 528 | 528 |
| 6 | 1.1.4 | 1.1.4 Determine Labor and Human Resources Costs | 4d | 2016-01-11 A | 2016-01-14 A |  | 100% |  |  | 2016-01-11 | 2016-01-14 | 4d |  | start no earlier than 2016-01-11 | Purchase Controller | 32h | 32h | 704 | 704 | 704 |
| 7 | 1.1.5 | 1.1.5 Create Annual Budget Recommendation | 2d | 2016-01-15 A | 2016-01-18 A |  | 100% |  |  | 2016-01-15 | 2016-01-18 | 2d |  | start no earlier than 2016-01-15 | Purchase Controller | 16h | 16h | 352 | 352 | 352 |
| 8 | 1.2 | **1.2 Design of the IT system** | 19d | 2016-01-05 A | 2016-01-29 | 3 | 99% | 0d |  | 2016-01-05 | 2016-01-29 | 19d | 0d |  |  | 200h | 152h | 7,840 | 7,840 | 5,920 |
| 9 | 1.2.1 | 1.2.1 Design data access | 2d | 2016-01-05 A | 2016-01-06 A |  | 100% |  |  | 2016-01-05 | 2016-01-06 | 2d |  |  | Cybersecurity Analyst | 16h | 16h | 640 | 640 | 640 |
| 10 | 1.2.2 | 1.2.2 Establish who can access data | 3d | 2016-01-07 A | 2016-01-11 A | 9 | 100% |  |  | 2016-01-07 | 2016-01-11 | 3d |  |  | Cybersecurity Analyst | 24h | 24h | 960 | 960 | 960 |
| 11 | 1.2.3 | **1.2.3 Develop secure systems for data storage** | 6d | 2016-01-14 A | 2016-01-21 | 9 | 99% | 0d |  | 2016-01-14 | 2016-01-21 | 6d |  |  | Cybersecurity Analyst | 96h | 48h | 3,840 | 3,840 | 1,920 |
| 12 | 1.2.3.1 | 1.2.3.1 Develop data back-up system | 4d | 2016-01-14 A | 2016-01-19 A |  | 100% |  |  | 2016-01-14 | 2016-01-19 | 4d |  |  | Cybersecurity Analyst | 32h | 32h | 1,280 | 1,280 | 1,280 |
| 13 | 1.2.3.2 | 1.2.3.2. Develop how to provide electronic version of patient data to patients if required | 2d | 2016-01-20 A | 2016-01-21 A | 12 | 100% |  |  | 2016-01-20 | 2016-01-21 | 2d |  |  | Cybersecurity Analyst | 16h | 16h | 640 | 640 | 640 |
| 14 | 1.2.4 | 1.2.4 Develop separate ID for data attained via telemedicine | 1d | 2016-01-22 A | 2016-01-22 A | 12 | 100% |  |  | 2016-01-22 | 2016-01-22 | 1d |  |  | Cybersecurity Analyst | 8h | 8h | 320 | 320 | 320 |
| 15 | 1.2.5 | 1.2.5 Determine Security Software | 2d | 2016-01-28 A | 2016-01-29 A | 12 | 100% |  |  | 2016-01-28 | 2016-01-29 | 2d |  | start no earlier than 2016-01-21 | Cybersecurity Analyst | 16h | 16h | 640 | 640 | 640 |
| 16 | 1.2.6 | 1.2.6 Create Security Policies | 3d | 2016-01-25 A | 2016-01-27 A |  | 100% |  |  | 2016-01-25 | 2016-01-27 | 3d |  | start no earlier than 2016-01-25 | Cybersecurity Analyst | 24h | 24h | 960 | 960 | 960 |
| 17 | 1.2.7 | 1.2.7 Determine Firewall Configuration | 2d | 2016-01-28 A | 2016-01-29 A |  | 100% |  |  | 2016-01-28 | 2016-01-29 | 2d |  | start no earlier than 2016-01-28 | Network Consultant | 16h | 16h | 480 | 480 | 480 |
| 18 | 1.3 | **1.3 Order software** | 3d | 2016-02-01 A | 2016-02-03 | 8 | 99% | 0d |  | 2016-02-01 | 2016-02-03 | 3d |  |  | Claims Software [1 License]; Google Apps [1 License]; Intuit QuickBooks 2016 [1 License]; Oracle Database Software [1 License]; Symantec Antivirus [1 License] | 8h | 8h | 11,261.9 | 5,722.95 | 184 |
| 19 | 1.3.1 | 1.3.1 Write up purchase orders | 1d | 2016-02-01 A | 2016-02-01 A |  | 100% |  |  | 2016-02-01 | 2016-02-01 | 1d |  |  | Business Administrator | 8h | 8h | 184 | 184 | 184 |
| 20 | 1.4 | **1.4 Order networking** | 1d | 2016-02-05 A | 2016-02-05 | 8 | 99% | 0d |  | 2016-02-05 | 2016-02-05 | 1d |  |  | Broadband Service [1 License]; Cat 6e Cable [1 Unit]; Docking Station [1 Unit]; Firewall [1 Unit]; Keyboard/Mouse [1 Unit]; Laptop [1 Unit]; Monitor [1 Unit]; RJ-45 Connector Tips [1 Pack]; RJ-45 Outlet [1 Unit]; Router [1 Unit]; Surge Protector [1 Unit]; Switch [1 Unit]; WiFi Range Extender [1 Unit]; WiFi Router [1 Unit] | 8h | 8h | 2,772.13 | 2,772.13 | 184 |
| 21 | 1.4.1 | 1.4.1 Write up purchase orders | 1d | 2016-02-05 A | 2016-02-05 A |  | 100% |  |  | 2016-02-05 | 2016-02-05 | 1d |  |  | Business Administrator | 8h | 8h | 184 | 184 | 184 |
| 22 | 1.4.2 | 1.4.2 Await deliveries and receivership of orders | 10d | 2016-02-01 A | 2016-02-12 A | 8 | 100% |  |  | 2016-02-01 | 2016-02-05 | 5d |  |  |  |  |  |  |  |  |
| 23 | 1.5 | **1.5 Install hardware** | 37d | 2016-03-08 | 2016-04-27 | 18, 20, 22 | 54% | 17.15d | 2016-02-08 | 2016-02-08 | 2016-03-29 | 37d |  |  |  | 328h | 176h | 21,560 | 11,480 | 10,920 |
| 24 | 1.5.1 | 1.5.1 Determine needs for each office | 5d | 2016-02-08 A | 2016-02-12 A |  | 100% |  |  | 2016-02-08 | 2016-02-12 | 5d |  |  | Project Manager | 40h | 40h | 1,400 | 1,400 | 1,400 |
| 25 | 1.5.2 | 1.5.2 Determine room readiness | 5d | 2016-04-07 | 2016-04-13 |  |  |  |  | 2016-03-09 | 2016-03-15 | 5d | 10d |  | Infrastructure Engineer | 40h |  | 2,800 | 1,400 |  |
| 26 | 1.5.3 | 1.5.3 Determine room layouts and specifications | 5d | 2016-04-14 | 2016-04-20 |  |  |  |  | 2016-03-16 | 2016-03-22 | 5d | 5d |  | Infrastructure Engineer | 40h |  | 2,800 | 1,400 |  |
| 27 | 1.5.4 | 1.5.4 Configure hardware | 10d | 2016-03-24 A | 2016-04-21 |  | 50% | 5d |  | 2016-02-24 | 2016-03-23 | 10d | 4d |  | Infrastructure Engineer | 80h | 40h | 5,600 | 2,800 | 2,800 |
| 28 | 1.5.5 | 1.5.5 Determine technical defects | 6d | 2016-03-08 A | 2016-03-15 A |  | 100% |  |  | 2016-02-08 | 2016-02-15 | 6d |  |  | Infrastructure Engineer | 48h | 48h | 3,360 | 1,680 | 3,360 |
| 29 | 1.5.6 | 1.5.6 Determine defects and make fixes | 4d | 2016-04-22 | 2016-04-27 |  |  |  |  | 2016-03-24 | 2016-03-29 | 4d | 0d |  | Infrastructure Engineer | 32h |  | 2,240 | 1,120 |  |
| 30 | 1.5.7 | 1.5.7 Remedy technical defects | 3d | 2016-03-16 A | 2016-03-18 A |  | 100% |  |  | 2016-02-16 | 2016-02-18 | 3d |  |  | Infrastructure Engineer | 24h | 24h | 1,680 | 840 | 1,680 |
| 31 | 1.5.8 | 1.5.8 Verify defect fixes | 3d | 2016-03-19 A | 2016-03-23 A | 28, 30 | 100% |  |  | 2016-02-19 | 2016-02-23 | 3d |  |  | Infrastructure Engineer | 24h | 24h | 1,680 | 840 | 1,680 |

| ID | WBS | Task | Duration | Start | Finish | Predecessors | Baseline start | Baseline finish | Baseline duration | Total slack | Free slack | Resources | Work | Cost | Baseline cost |
| --- | --- | --- | --- | --- | --- | --- | --- | --- | --- | --- | --- | --- | --- | --- | --- |
| 32 | 1.6 | **1.6 Install Software** | 49d | 2016-04-28 | 2016-07-05 | 23 | 2016-03-30 | 2016-06-03 | 48d | -124d | 0d | HIPAA Auditor | 768h | 58,880 | 45,440 |
| 33 | 1.6.1 | 1.6.1 Install patient registration component | 12d | 2016-04-28 | 2016-07-05 |  | 2016-03-30 | 2016-04-14 | 12d | -124d | 0d | Infrastructure Engineer | 96h | 6,720 | 3,360 |
| 34 | 1.6.2 | 1.6.2 Check on Cisco Vital Software Interface requirements | 12d | 2016-04-28 | 2016-06-01 |  | 2016-03-30 | 2016-04-14 | 12d | -100d | 0d | Network Consultant | 96h | 2,880 | 2,880 |
| 35 | 1.6.3 | 1.6.3 Verify that Cisco Vital Software and Third Party medical devices meet requirements | 12d | 2016-05-03 | 2016-05-18 |  | 2016-03-30 | 2016-04-14 | 12d | -90d | 0d | Project Manager | 96h | 3,360 | 3,360 |
| 36 | 1.6.4 | 1.6.4 Produce mockups with hyperlinks to requirements | 12d | 2016-05-16 | 2016-05-31 |  | 2016-04-15 | 2016-05-02 | 12d | -99d | 0d | Network Consultant | 96h | 2,880 | 2,880 |
| 37 | 1.6.5 | 1.6.5 System testing | 12d | 2016-06-02 | 2016-06-17 |  | 2016-05-04 | 2016-05-19 | 12d | -112d | 0d | Network Consultant | 96h | 2,880 | 2,880 |
| 38 | 1.6.6 | 1.6.6 Develop user interface | 12d | 2016-05-16 | 2016-05-31 |  | 2016-04-15 | 2016-05-02 | 12d | -99d | 0d | Infrastructure Engineer | 96h | 6,720 | 3,360 |
| 39 | 1.6.7 | 1.6.7 Configure the software | 12d | 2016-06-01 | 2016-06-16 |  | 2016-05-03 | 2016-05-18 | 12d | -111d | 0d | Infrastructure Engineer | 96h | 6,720 | 3,360 |
| 40 | 1.6.8 | 1.6.8 Perform integration testing | 12d | 2016-06-17 | 2016-07-04 |  | 2016-05-19 | 2016-06-03 | 12d | -123d | 0d | Infrastructure Engineer | 96h | 6,720 | 3,360 |
| 41 | 1.7 | **1.7 Install networking** | 26d | 2016-04-08 | 2016-05-13 | 32 | 2016-03-08 | 2016-04-12 | 26d |  |  |  | 256h | 12,424 | 7,944 |
| 42 | 1.7.1 | 1.7.1 Determine network needs | 8d | 2016-07-06 | 2016-07-15 |  | 2016-06-15 | 2016-06-24 | 8d | -45d | 0d | Infrastructure Engineer | 64h | 4,480 | 2,240 |
| 43 | 1.7.2 | 1.7.2 Determine networking infrastructure needs | 8d | 2016-05-09 | 2016-08-15 |  | 2016-03-08 | 2016-06-14 | 8d | -82d | 0d | Infrastructure Engineer | 64h | 4,480 | 2,240 |
| 44 | 1.7.3 | 1.7.3 Configure Financial Management Software | 3d | 2016-08-16 | 2016-08-18 | 43 | 2016-06-15 | 2016-06-17 | 3d | -82d | 0d | Software Development Manager | 24h | 672 | 672 |
| 45 | 1.7.4 | 1.7.4 Configure Insurance Management Software | 4d | 2016-08-19 | 2016-08-24 | 44 | 2016-06-20 | 2016-06-23 | 4d | -82d | 0d | Software Development Manager | 32h | 896 | 896 |
| 46 | 1.7.5 | 1.7.5 Configure Xray Management Software | 4d | 2016-08-25 | 2016-08-30 | 45 | 2016-06-24 | 2016-06-29 | 4d | -82d | 0d | Software Development Manager | 32h | 896 | 896 |
| 47 | 1.7.6 | 1.7.6 Test all software | 5d | 2016-08-31 | 2016-09-06 | 46 | 2016-06-30 | 2016-07-06 | 5d | -82d | 0d | QA Engineer | 40h | 1,000 | 1,000 |
| 48 | 1.8 | **1.8 Create management protocol** | 5d | 2016-04-08 | 2016-04-14 |  | 2016-04-08 | 2016-04-14 | 5d |  |  |  | 16h | 640 | 640 |
| 49 | 1.8.1 | 1.8.1 Create maintenance plan | 1d | 2016-04-08 | 2016-04-08 |  | 2016-04-08 | 2016-04-08 | 1d | 4d |  | Cybersecurity Analyst | 8h | 320 | 320 |
| 51 | 1.8.2 | 1.8.2 Create maintenance notification messaging | 1d | 2016-04-11 | 2016-04-11 |  | 2016-04-11 | 2016-04-11 | 1d | 3d |  | Cybersecurity Analyst | 8h | 320 | 320 |
| 52 | 1.9 | **1.9 Manage the project and team** | 9d | 2016-04-15 | 2016-04-27 | 48 | 2016-04-15 | 2016-04-27 | 9d | 4d |  |  | 72h | 2,184 | 2,184 |
| 53 | 1.9.1 | **1.9.1 Review of the workplan** | 5d | 2016-04-21 | 2016-04-27 |  | 2016-04-21 | 2016-04-27 | 5d |  |  |  | 48h | 1,512 | 1,512 |
| 54 | 1.9.1.1 | 1.9.1.1 Identify completed activities | 3d | 2016-04-21 | 2016-04-25 |  | 2016-04-21 | 2016-04-25 | 3d | 2d |  | Project Manager | 24h | 840 | 840 |
| 55 | 1.9.1.2 | 1.9.1.2 Check for variances in the schedule | 3d | 2016-04-21 | 2016-04-25 |  | 2016-04-21 | 2016-04-25 | 3d | 2d |  | Associate Project Manager | 24h | 672 | 672 |
| 56 | 1.9.2 | 1.9.2 Review the team morale | 3d | 2016-04-15 | 2016-04-19 |  | 2016-04-15 | 2016-04-19 | 3d | 31d |  | Associate Project Manager | 24h | 672 | 672 |

| ID | WBS | Task | Duration | Start | Finish | Predecessors | Baseline start | Baseline finish | Baseline duration | Total slack | Free slack | Constraint | Resources | Work | Cost | Baseline cost |
| --- | --- | --- | --- | --- | --- | --- | --- | --- | --- | --- | --- | --- | --- | --- | --- | --- |
| 57 | 1.10 | **1.10 Control of the Project** | 9d | 2016-04-15 | 2016-04-27 | 48 | 2016-04-15 | 2016-04-27 | 9d | 25d |  |  |  | 48h | 1,680 | 1,680 |
| 58 | 1.10.1 | 1.10.1 Guard against scope creep | 3d | 2016-04-15 | 2016-04-19 |  | 2016-04-15 | 2016-04-19 | 3d | 31d |  |  | Project Manager | 24h | 840 | 840 |
| 59 | 1.10.2 | 1.10.2 Check for the need for scope changes | 3d | 2016-04-20 | 2016-04-27 |  | 2016-04-20 | 2016-04-27 | 3d | 25d |  |  | Project Manager | 24h | 840 | 840 |
| 60 | 1.11 | **1.11 Monitor the Project** | 12d | 2016-04-15 | 2016-05-02 | 48 | 2016-04-15 | 2016-05-02 | 12d | 22d |  |  |  | 48h | 1,800 | 1,800 |
| 61 | 1.11.1 | 1.11.1 Evaluate project deliverables | 3d | 2016-04-28 | 2016-05-02 |  | 2016-04-28 | 2016-05-02 | 3d | 22d |  |  | Project Manager | 24h | 840 | 840 |
| 62 | 1.11.2 | 1.11.2 Check on the budget | 3d | 2016-04-15 | 2016-04-19 |  | 2016-04-15 | 2016-04-19 | 3d | 31d |  |  | Finance Manager | 24h | 960 | 960 |
| 63 | 1.12 | **1.12 Project Meetings and Training** | 16d | 2016-09-07 | 2016-09-28 | 52, 57, 60 | 2016-05-03 | 2016-05-24 | 16d |  |  |  |  | 168h | 3,240 | 3,240 |
| 64 | 1.12.1 | 1.12.1 Define users | 1d | 2016-09-07 | 2016-09-07 |  | 2016-05-03 | 2016-05-03 | 1d | 15d |  |  | Network Consultant | 8h | 240 | 240 |
| 65 | 1.12.2 | 1.12.2 Explain in basic terms how systems hardware and software works | 1d | 2016-09-07 | 2016-09-07 |  | 2016-05-03 | 2016-05-03 | 1d | 15d |  |  | Software Development Manager | 8h | 224 | 224 |
| 66 | 1.12.3 | 1.12.3 Explain how to interpret data | 1d | 2016-09-07 | 2016-09-07 |  | 2016-05-03 | 2016-05-03 | 1d | 15d |  |  | Database Manager | 8h | 256 | 256 |
| 67 | 1.12.4 | 1.12.4 Explain how to store data properly | 1d | 2016-09-08 | 2016-09-08 |  | 2016-05-04 | 2016-05-04 | 1d | 14d |  |  | Database Manager | 8h | 256 | 256 |
| 68 | 1.12.5 | 1.12.5 Receptionist Training | 5d | 2016-09-07 | 2016-09-13 |  | 2016-05-03 | 2016-05-09 | 5d | -1d | 0d | start no earlier than 2016-09-07 | Trainer | 40h | 600 | 600 |
| 69 | 1.12.6 | 1.12.6 Dental Staff Training | 5d | 2016-09-14 | 2016-09-20 | 68 | 2016-05-10 | 2016-05-16 | 5d | -1d | 0d |  | Trainer | 40h | 600 | 600 |
| 70 | 1.12.7 | 1.12.7 Accounting and Administrative Training | 5d | 2016-09-21 | 2016-09-27 | 69 | 2016-05-17 | 2016-05-23 | 5d | -1d | 0d | start no earlier than 2016-05-16 | Trainer | 40h | 600 | 600 |
| 71 | 1.12.8 | 1.12.8 Quiz session | 1d | 2016-09-28 | 2016-09-28 | 70 | 2016-05-23 | 2016-05-23 | 1d | -1d | 0d | start no earlier than 2016-05-23 | Business Administrator | 8h | 184 | 184 |
| 72 | 1.12.9 | 1.12.9 List responsibilities of IT liaison | 1d | 2016-09-29 | 2016-09-29 | 71 | 2016-05-24 | 2016-05-24 | 1d | -1d | 0d |  | Project Manager | 8h | 280 | 280 |
| 73 | 1.13 | **1.13 Project close-out** | 4d | 2016-09-30 | 2016-10-05 | 63 | 2016-05-25 | 2016-05-30 | 4d |  |  |  |  | 48h | 1,624 | 1,624 |
| 74 | 1.13.1 | 1.13.1 Close out documentation | 2d | 2016-09-30 | 2016-10-03 |  | 2016-05-25 | 2016-05-26 | 2d | -1d | 0d |  | Project Manager | 16h | 560 | 560 |
| 75 | 1.13.2 | 1.13.2 Outline lessons learned | 2d | 2016-10-04 | 2016-10-06 | 74 | 2016-05-27 | 2016-05-30 | 2d | -1d | 0d |  | Project Manager | 16h | 560 | 560 |
| 76 | 1.13.3 | 1.13.3 Project closure phase complete | 2d | 2016-10-04 | 2016-10-05 | 74 | 2016-05-30 | 2016-05-31 | 2d | 1d |  | start no earlier than 2016-05-30 | Associate Project Manager; Project Manager | 16h | 504 | 504 |
